# ESP schedule_v4

Schedule from MS Project, 2005-12-14 to 2008-01-03, A marks actual dates.
MBARI

## Calendars

- Standard: Mon-Fri 08:00-12:00, 13:00-17:00; Sat-Sun off.

## Resources

| Resource |
| --- |
| Scott |
| Gene |
| Brent |
| Chris S. |
| Chris P. |
| Roman |
| Mark Brown |
| Science Team |
| Bob |

## Schedule

| ID | WBS | Task | Type | Duration | Start | Finish | Complete | Remaining | Baseline start | Baseline finish | Baseline duration | Total slack | Constraint | Resources | Work | Actual work |
| --- | --- | --- | --- | --- | --- | --- | --- | --- | --- | --- | --- | --- | --- | --- | --- | --- |
| 1 | 1 | **GiGi core** |  | 55d? | 2005-12-14 A | 2006-02-28 | 14% | 47.19d? | 2005-12-14 | 2006-01-04 | 16d? | 482d |  |  | 828h | 36h |
| 2 | 1.1 | Final instrument modifications |  | 1d? | 2006-01-04 | 2006-01-04 |  |  | 2006-01-04 | 2006-01-04 | 1d? | 521d |  |  |  |  |
| 4 | 1.2 | **Refit system valves to Cheminert valves** |  | 40d? | 2005-12-14 A | 2006-02-07 | 41% | 23.68d? | 2005-12-14 | 2006-01-04 | 16d? | 497d |  |  | 148h | 36h |
| 5 | 1.2.1 | Order new valves |  | 0.5d | 2005-12-14 A | 2005-12-14 A | 100% |  | 2005-12-14 | 2005-12-14 | 0.5d |  | start no earlier than 2005-12-14 | Scott | 4h | 4h |
| 6 | 1.2.2 | Split cost of valves | milestone | 0d | 2006-01-04 | 2006-01-04 |  |  | 2006-01-04 | 2006-01-04 | 0d? | 522d |  |  |  |  |
| 7 | 1.2.3 | Valves arrive | milestone | 0d | 2006-01-04 | 2006-01-04 |  |  | 2006-01-04 | 2006-01-04 | 1d? | 522d |  |  |  |  |
| 9 | 1.2.4 | **Valve bracket redesign** |  | 2d? | 2006-01-04 A | 2006-01-05 A | 100% |  | 2006-01-04 | 2006-01-04 | 1d? |  |  |  | 32h | 32h |
| 10 | 1.2.4.1 | **Design** |  | 2d? | 2006-01-04 A | 2006-01-05 A | 100% |  | 2006-01-04 | 2006-01-04 | 1d? |  |  |  | 24h | 24h |
| 11 | 1.2.4.1.1 | EE |  | 1.43d? | 2006-01-04 A | 2006-01-05 A | 100% |  | 2006-01-04 | 2006-01-04 | 1d? |  |  | Scott [70%] | 8h | 8h |
| 12 | 1.2.4.1.2 | ME |  | 2d? | 2006-01-04 A | 2006-01-05 A | 100% |  | 2006-01-04 | 2006-01-04 | 1d? |  |  | Gene [50%] | 8h | 8h |
| 13 | 1.2.4.1.3 | SE |  | 1.43d? | 2006-01-04 A | 2006-01-05 A | 100% |  | 2006-01-04 | 2006-01-04 | 1d? |  |  | Brent [70%] | 8h | 8h |
| 14 | 1.2.4.2 | **Part procurment** |  | 2d? | 2006-01-04 A | 2006-01-05 A | 100% |  | 2006-01-04 | 2006-01-04 | 1d? |  |  |  | 8h | 8h |
| 15 | 1.2.4.2.1 | ME Tech |  | 1d? | 2006-01-04 A | 2006-01-04 A | 100% |  | 2006-01-04 | 2006-01-04 | 1d? |  |  |  |  |  |
| 16 | 1.2.4.2.2 | ME |  | 2d? | 2006-01-04 A | 2006-01-05 A | 100% |  | 2006-01-04 | 2006-01-04 | 1d? |  |  | Gene [50%] | 8h | 8h |
| 17 | 1.2.4.3 | **fabrication** |  | 1d? | 2006-01-04 A | 2006-01-04 A | 100% |  | 2006-01-04 | 2006-01-04 | 1d? |  |  |  |  |  |
| 18 | 1.2.4.3.1 | METech |  | 1d? | 2006-01-04 A | 2006-01-04 A | 100% |  | 2006-01-04 | 2006-01-04 | 1d? |  |  |  |  |  |
| 19 | 1.2.4.3.2 | ME |  | 1d? | 2006-01-04 A | 2006-01-04 A | 100% |  | 2006-01-04 | 2006-01-04 | 1d? |  |  |  |  |  |
| 20 | 1.2.4.3.3 | EE |  | 1d? | 2006-01-04 A | 2006-01-04 A | 100% |  | 2006-01-04 | 2006-01-04 | 1d? |  |  |  |  |  |
| 21 | 1.2.4.4 | **Assembly** |  | 1d? | 2006-01-04 A | 2006-01-04 A | 100% |  | 2006-01-04 | 2006-01-04 | 1d? |  |  |  |  |  |
| 22 | 1.2.4.4.1 | ME Tech |  | 1d? | 2006-01-04 A | 2006-01-04 A | 100% |  | 2006-01-04 | 2006-01-04 | 1d? |  |  |  |  |  |
| 23 | 1.2.5 | **Valve placement in instrument** |  | 1d? | 2006-01-04 A | 2006-01-04 | 90% | 0.1d? | 2006-01-04 | 2006-01-04 | 1d? | 521d |  |  |  |  |
| 24 | 1.2.5.1 | Physical modelling for valve placement |  | 1d? | 2006-01-04 A | 2006-01-04 A | 100% |  | 2006-01-04 | 2006-01-04 | 1d? |  |  |  |  |  |
| 25 | 1.2.5.2 | **Instrument modifications** |  | 1d? | 2006-01-04 A | 2006-01-04 A | 100% |  | 2006-01-04 | 2006-01-04 | 1d? |  |  |  |  |  |
| 26 | 1.2.5.2.1 | **Fabrication** |  | 1d? | 2006-01-04 A | 2006-01-04 A | 100% |  | 2006-01-04 | 2006-01-04 | 1d? |  |  |  |  |  |
| 27 | 1.2.5.2.1.1 | ME tech |  | 1d? | 2006-01-04 A | 2006-01-04 A | 100% |  | 2006-01-04 | 2006-01-04 | 1d? |  |  |  |  |  |
| 28 | 1.2.5.2.1.2 | ME |  | 1d? | 2006-01-04 A | 2006-01-04 A | 100% |  | 2006-01-04 | 2006-01-04 | 1d? |  |  |  |  |  |
| 29 | 1.2.5.2.1.3 | shop |  | 1d? | 2006-01-04 A | 2006-01-04 A | 100% |  | 2006-01-04 | 2006-01-04 | 1d? |  |  |  |  |  |

Notes:
- 5: Placed order with VICI with two PO's / PO-0512876 4,6,8 using C25-618x vavles / PO-0512876 for custom 4 port loop C22-6184-MBA / Custom was $base+25 and +1wk
- 7: Standard valves arrived ealry than planned 12/21/05 / Waiting for custom

| ID | WBS | Task | Duration | Start | Finish | Complete | Baseline start | Baseline finish | Baseline duration | Total slack | Constraint | Resources | Work |
| --- | --- | --- | --- | --- | --- | --- | --- | --- | --- | --- | --- | --- | --- |
| 30 | 1.2.5.2.2 | **assembly** | 1d? | 2006-01-04 A | 2006-01-04 A | 100% | 2006-01-04 | 2006-01-04 | 1d? |  |  |  |  |
| 31 | 1.2.5.2.2.1 | ME tech | 1d? | 2006-01-04 A | 2006-01-04 A | 100% | 2006-01-04 | 2006-01-04 | 1d? |  |  |  |  |
| 32 | 1.2.5.2.2.2 | ME | 1d? | 2006-01-04 A | 2006-01-04 A | 100% | 2006-01-04 | 2006-01-04 | 1d? |  |  |  |  |
| 33 | 1.2.5.2.2.3 | shop | 1d? | 2006-01-04 A | 2006-01-04 A | 100% | 2006-01-04 | 2006-01-04 | 1d? |  |  |  |  |
| 34 | 1.2.5.2.2.4 | EE | 1d? | 2006-01-04 A | 2006-01-04 A | 100% | 2006-01-04 | 2006-01-04 | 1d? |  |  |  |  |
| 35 | 1.2.5.2.2.5 | SE | 1d? | 2006-01-04 A | 2006-01-04 A | 100% | 2006-01-04 | 2006-01-04 | 1d? |  |  |  |  |
| 36 | 1.2.5.3 | **Testing** | 1d? | 2006-01-04 | 2006-01-04 |  | 2006-01-04 | 2006-01-04 | 1d? | 521d |  |  |  |
| 37 | 1.2.5.3.1 | EE | 1d? | 2006-01-04 | 2006-01-04 |  | 2006-01-04 | 2006-01-04 | 1d? | 521d |  |  |  |
| 38 | 1.2.6 | Protocol redevelopment | 10d | 2006-01-25 | 2006-02-07 |  | 2006-01-04 | 2006-01-04 | 1d? | 497d | start no earlier than 2006-01-25 | Science Team | 80h |
| 39 | 1.2.7 | **Refit completion** | 20d? | 2006-01-04 | 2006-01-31 |  | 2006-01-04 | 2006-01-04 | 1d? | 502d |  |  | 32h |
| 40 | 1.2.7.1 | Model and drawing update - MB | 20d? | 2006-01-04 | 2006-01-31 |  | 2006-01-04 | 2006-01-04 | 1d? | 502d |  | Mark Brown [20%] | 32h |
| 42 | 1.3 | **modify bulkhead valves - eliminate solenoid** | 1d? | 2006-01-04 | 2006-01-04 |  | 2006-01-04 | 2006-01-04 | 1d? | 521d |  |  | 280h |
| 43 | 1.3.1 | **design** | 1d? | 2006-01-04 | 2006-01-04 |  | 2006-01-04 | 2006-01-04 | 1d? | 521d |  |  | 112h |
| 44 | 1.3.1.1 | EE | 1d? | 2006-01-04 | 2006-01-04 |  | 2006-01-04 | 2006-01-04 | 1d? | 521d |  |  | 40h |
| 45 | 1.3.1.2 | ME | 1d? | 2006-01-04 | 2006-01-04 |  | 2006-01-04 | 2006-01-04 | 1d? | 521d |  |  | 56h |
| 46 | 1.3.1.3 | SE | 1d? | 2006-01-04 | 2006-01-04 |  | 2006-01-04 | 2006-01-04 | 1d? | 521d |  |  | 16h |
| 47 | 1.3.2 | **Fabricate** | 1d? | 2006-01-04 | 2006-01-04 |  | 2006-01-04 | 2006-01-04 | 1d? | 521d |  |  | 72h |
| 48 | 1.3.2.1 | EE | 1d? | 2006-01-04 | 2006-01-04 |  | 2006-01-04 | 2006-01-04 | 1d? | 521d |  |  | 16h |
| 49 | 1.3.2.2 | ME | 1d? | 2006-01-04 | 2006-01-04 |  | 2006-01-04 | 2006-01-04 | 1d? | 521d |  |  | 8h |
| 50 | 1.3.2.3 | ME Tech | 1d? | 2006-01-04 | 2006-01-04 |  | 2006-01-04 | 2006-01-04 | 1d? | 521d |  |  | 16h |
| 51 | 1.3.2.4 | EE Tech | 1d? | 2006-01-04 | 2006-01-04 |  | 2006-01-04 | 2006-01-04 | 1d? | 521d |  |  | 8h |
| 52 | 1.3.2.5 | Shop | 1d? | 2006-01-04 | 2006-01-04 |  | 2006-01-04 | 2006-01-04 | 1d? | 521d |  |  | 24h |
| 53 | 1.3.3 | **test and integrate** | 1d? | 2006-01-04 | 2006-01-04 |  | 2006-01-04 | 2006-01-04 | 1d? | 521d |  |  | 96h |
| 54 | 1.3.3.1 | EE | 1d? | 2006-01-04 | 2006-01-04 |  | 2006-01-04 | 2006-01-04 | 1d? | 521d |  |  | 40h |
| 55 | 1.3.3.2 | ME | 1d? | 2006-01-04 | 2006-01-04 |  | 2006-01-04 | 2006-01-04 | 1d? | 521d |  |  | 16h |
| 56 | 1.3.3.3 | SE | 1d? | 2006-01-04 | 2006-01-04 |  | 2006-01-04 | 2006-01-04 | 1d? | 521d |  |  | 16h |
| 57 | 1.3.3.4 | ME Tech | 1d? | 2006-01-04 | 2006-01-04 |  | 2006-01-04 | 2006-01-04 | 1d? | 521d |  |  | 24h |

| ID | WBS | Task | Duration | Start | Finish | Baseline start | Baseline finish | Baseline duration | Total slack | Free slack | Constraint | Resources | Work |
| --- | --- | --- | --- | --- | --- | --- | --- | --- | --- | --- | --- | --- | --- |
| 59 | 1.4 | **Software** | 40d | 2006-01-04 | 2006-02-28 | 2006-01-04 | 2006-02-28 | 40d | 470d |  |  |  | 400h |
| 60 | 1.4.1 | **Contextual Sensors** | 30d | 2006-01-04 | 2006-02-14 | 2006-01-04 | 2006-02-14 | 30d | 492d |  |  |  | 280h |
| 61 | 1.4.1.1 | SE | 30d | 2006-01-04 | 2006-02-14 | 2006-01-04 | 2006-02-14 | 30d | 492d |  |  | Brent [16.7%] | 40h |
| 62 | 1.4.1.2 | External SE | 30d | 2006-01-04 | 2006-02-14 | 2006-01-04 | 2006-02-14 | 30d | 492d |  |  | Bob | 240h |
| 63 | 1.4.2 | Power cycling | 25d | 2006-01-25 | 2006-02-28 | 2006-01-25 | 2006-02-28 | 25d | 455d | 0d | start no earlier than 2006-01-25 | Brent [60%] | 120h |
| 65 | 2 | **shutter on sample intake port (50m depth max)** | 1d? | 2006-01-04 | 2006-01-04 | 2006-01-04 | 2006-01-04 | 1d? | 521d |  |  |  | 328h |
| 66 | 2.1 | **design** | 1d? | 2006-01-04 | 2006-01-04 | 2006-01-04 | 2006-01-04 | 1d? | 521d |  |  |  | 120h |
| 67 | 2.1.1 | EE | 1d? | 2006-01-04 | 2006-01-04 | 2006-01-04 | 2006-01-04 | 1d? | 521d |  |  |  | 40h |
| 68 | 2.1.2 | ME | 1d? | 2006-01-04 | 2006-01-04 | 2006-01-04 | 2006-01-04 | 1d? | 521d |  |  |  | 64h |
| 69 | 2.1.3 | SE | 1d? | 2006-01-04 | 2006-01-04 | 2006-01-04 | 2006-01-04 | 1d? | 521d |  |  |  | 16h |
| 70 | 2.2 | **Fabricate** | 1d? | 2006-01-04 | 2006-01-04 | 2006-01-04 | 2006-01-04 | 1d? | 521d |  |  |  | 112h |
| 71 | 2.2.1 | EE | 1d? | 2006-01-04 | 2006-01-04 | 2006-01-04 | 2006-01-04 | 1d? | 521d |  |  |  | 16h |
| 72 | 2.2.2 | ME | 1d? | 2006-01-04 | 2006-01-04 | 2006-01-04 | 2006-01-04 | 1d? | 521d |  |  |  | 8h |
| 73 | 2.2.3 | ME Tech | 1d? | 2006-01-04 | 2006-01-04 | 2006-01-04 | 2006-01-04 | 1d? | 521d |  |  |  | 16h |
| 74 | 2.2.4 | EE Tech | 1d? | 2006-01-04 | 2006-01-04 | 2006-01-04 | 2006-01-04 | 1d? | 521d |  |  |  | 8h |
| 75 | 2.2.5 | Shop | 1d? | 2006-01-04 | 2006-01-04 | 2006-01-04 | 2006-01-04 | 1d? | 521d |  |  |  | 64h |
| 76 | 2.3 | **test and integrate** | 1d? | 2006-01-04 | 2006-01-04 | 2006-01-04 | 2006-01-04 | 1d? | 521d |  |  |  | 96h |
| 77 | 2.3.1 | EE | 1d? | 2006-01-04 | 2006-01-04 | 2006-01-04 | 2006-01-04 | 1d? | 521d |  |  |  | 40h |
| 78 | 2.3.2 | ME | 1d? | 2006-01-04 | 2006-01-04 | 2006-01-04 | 2006-01-04 | 1d? | 521d |  |  |  | 16h |
| 79 | 2.3.3 | SE | 1d? | 2006-01-04 | 2006-01-04 | 2006-01-04 | 2006-01-04 | 1d? | 521d |  |  |  | 16h |
| 80 | 2.3.4 | ME Tech | 1d? | 2006-01-04 | 2006-01-04 | 2006-01-04 | 2006-01-04 | 1d? | 521d |  |  |  | 24h |
| 82 | 3 | **Software** | 1d? | 2006-01-04 | 2006-01-04 | 2006-01-04 | 2006-01-04 | 1d? | 521d |  |  |  | 280h |
| 83 | 3.1 | GUI | 1d? | 2006-01-04 | 2006-01-04 | 2006-01-04 | 2006-01-04 | 1d? | 521d |  |  |  |  |
| 84 | 3.2 | annimator | 1d? | 2006-01-04 | 2006-01-04 | 2006-01-04 | 2006-01-04 | 1d? | 521d |  |  |  | 280h |

| ID | WBS | Task | Duration | Start | Finish | Predecessors | Baseline start | Baseline finish | Baseline duration | Total slack | Free slack | Constraint | Resources | Work |
| --- | --- | --- | --- | --- | --- | --- | --- | --- | --- | --- | --- | --- | --- | --- |
| 86 | 4 | **Finish surface surface water housing for GiGi** | 35d | 2006-01-25 | 2006-03-14 |  | 2006-01-04 | 2006-01-04 | 1d? | 472d |  |  |  | 24h |
| 87 | 4.1 | **Pressure housing for GiGi - surface water - 50m** | 35d | 2006-01-25 | 2006-03-14 |  | 2006-01-04 | 2006-01-04 | 1d? | 472d |  |  |  | 24h |
| 88 | 4.1.1 | **Design** | 8d | 2006-01-25 | 2006-02-03 |  | 2006-01-04 | 2006-01-04 | 1d? | 472d | 0d |  |  | 8h |
| 89 | 4.1.1.1 | ME | 8d | 2006-01-25 | 2006-02-03 |  | 2006-01-25 | 2006-02-03 | 8d | 472d |  | start no earlier than 2006-01-25 | Gene [12.5%] | 8h |
| 90 | 4.1.2 | **assembly** | 25d | 2006-02-06 | 2006-03-10 | 88 | 2006-01-04 | 2006-01-04 | 1d? | 472d | 0d |  |  | 8h |
| 91 | 4.1.2.1 | Outside fab | 25d | 2006-02-06 | 2006-03-10 |  | 2006-02-06 | 2006-03-10 | 25d | 472d |  |  |  |  |
| 92 | 4.1.2.2 | ME tech | 2d | 2006-02-06 | 2006-02-07 |  | 2006-02-06 | 2006-02-07 | 2d | 495d |  |  |  | 8h |
| 93 | 4.1.3 | **Pressure test** | 2d | 2006-03-13 | 2006-03-14 | 90 | 2006-01-04 | 2006-01-04 | 1d? | 472d |  |  |  | 8h |
| 94 | 4.1.3.1 | ME tech | 2d | 2006-03-13 | 2006-03-14 |  | 2006-03-13 | 2006-03-14 | 2d | 472d |  |  |  | 8h |
| 96 | 5 | **Mooring 2 battery configuration** | 27d? | 2006-01-04 | 2006-02-09 |  | 2006-01-04 | 2006-02-09 | 27d? | 474d |  |  |  |  |
| 97 | 5.1 | Mechanical | 1d? | 2006-01-04 | 2006-01-04 |  | 2006-01-04 | 2006-01-04 | 1d? | 499d | 25d |  |  |  |
| 98 | 5.2 | **Electrical** | 1d? | 2006-02-09 | 2006-02-09 | 97 | 2006-02-09 | 2006-02-09 | 1d? | 474d | 16d |  |  |  |
| 99 | 5.2.1 | Battery order | 1d? | 2006-02-09 | 2006-02-09 |  | 2006-02-09 | 2006-02-09 | 1d? | 474d |  | finish no earlier than 2006-02-09 |  |  |
| 100 | 5.2.2 | Cable configuration | 1d? | 2006-02-09 | 2006-02-09 |  | 2006-02-09 | 2006-02-09 | 1d? | 474d |  | finish no earlier than 2006-02-09 |  |  |
| 106 | 6 | Tank Deployment | 1d | 2006-03-06 | 2006-03-06 | 98 | 2006-03-03 | 2006-03-03 | 1d? | 458d | 1d | start no earlier than 2006-03-06 |  | 8h |
| 109 | 7 | **Shallow water deployments** | 149d? | 2006-03-08 | 2006-10-02 | 106 | 2006-01-04 | 2006-03-08 | 45d? | 328d |  |  |  | 480h |
| 110 | 7.1 | **Deployment 1 Zephyr** | 14d? | 2006-03-08 | 2006-03-27 |  | 2006-01-04 | 2006-03-08 | 45d? | 463d |  |  |  | 52h |
| 111 | 7.1.1 | MOB | 1d | 2006-03-08 | 2006-03-09 | 115SF | 2006-01-04 | 2006-01-04 | 1d? | 475d | 0d | start no earlier than 2006-03-08 |  |  |
| 112 | 7.1.2 | **MOB resources** | 1d? | 2006-03-08 | 2006-03-08 | 111SS | 2006-03-08 | 2006-03-08 | 1d? | 476d |  |  |  | 12h |
| 113 | 7.1.2.1 | EE | 1d? | 2006-03-08 | 2006-03-08 |  | 2006-03-08 | 2006-03-08 | 1d? | 476d |  |  |  | 8h |
| 114 | 7.1.2.2 | ME | 1d? | 2006-03-08 | 2006-03-08 |  | 2006-03-08 | 2006-03-08 | 1d? | 476d |  |  |  | 4h |
| 115 | 7.1.3 | Deployment | 13d | 2006-03-09 | 2006-03-27 |  | 2006-03-08 | 2006-03-08 | 13d | 463d | 0d | start no earlier than 2006-03-09 |  |  |
| 116 | 7.1.4 | **Deployment resources** | 13d? | 2006-03-09 | 2006-03-27 |  | 2006-03-09 | 2006-03-27 | 13d? | 463d |  |  |  | 40h |
| 117 | 7.1.4.1 | **Deploy** | 1d? | 2006-03-09 | 2006-03-09 | 115SS | 2006-03-09 | 2006-03-09 | 1d? | 475d |  |  |  | 20h |
| 118 | 7.1.4.1.1 | EE | 1d? | 2006-03-09 | 2006-03-09 |  | 2006-03-09 | 2006-03-09 | 1d? | 475d |  |  |  | 12h |
| 119 | 7.1.4.1.2 | ME | 1d? | 2006-03-09 | 2006-03-09 |  | 2006-03-09 | 2006-03-09 | 1d? | 475d |  |  |  | 8h |

| ID | WBS | Task | Duration | Start | Finish | Predecessors | Baseline start | Baseline finish | Baseline duration | Total slack | Free slack | Constraint | Work |
| --- | --- | --- | --- | --- | --- | --- | --- | --- | --- | --- | --- | --- | --- |
| 120 | 7.1.4.2 | **Recover** | 2d | 2006-03-24 | 2006-03-27 |  | 2006-03-24 | 2006-03-27 | 2d | 463d |  |  | 20h |
| 121 | 7.1.4.2.1 | EE | 2d | 2006-03-24 | 2006-03-27 | 115FF | 2006-03-24 | 2006-03-27 | 2d | 463d |  |  | 12h |
| 122 | 7.1.4.2.2 | ME | 2d | 2006-03-24 | 2006-03-27 | 115FF | 2006-03-24 | 2006-03-27 | 2d | 463d |  |  | 8h |
| 123 | 7.2 | **Deployment 2 Zephyr** | 16d? | 2006-04-03 | 2006-04-24 |  | 2006-01-04 | 2006-03-08 | 45d? | 443d |  |  | 36h |
| 124 | 7.2.1 | MOB | 1d | 2006-04-03 | 2006-04-03 | 128SS | 2006-01-04 | 2006-01-04 | 1d? | 458d | 0d | start no earlier than 2006-03-08 |  |
| 125 | 7.2.2 | **MOB resources** | 1d? | 2006-04-03 | 2006-04-03 | 124SS | 2006-04-03 | 2006-04-03 | 1d? | 458d |  |  | 12h |
| 126 | 7.2.2.1 | EE | 1d? | 2006-04-03 | 2006-04-03 |  | 2006-04-03 | 2006-04-03 | 1d? | 458d |  |  | 8h |
| 127 | 7.2.2.2 | ME | 1d? | 2006-04-03 | 2006-04-03 |  | 2006-04-03 | 2006-04-03 | 1d? | 458d |  |  | 4h |
| 128 | 7.2.3 | Deployment | 16d | 2006-04-03 | 2006-04-24 |  | 2006-03-08 | 2006-03-08 | 16d | 443d | 0d | finish no earlier than 2006-04-24 |  |
| 129 | 7.2.4 | **Deployment resources** | 11d? | 2006-04-10 | 2006-04-24 |  | 2006-04-03 | 2006-04-24 | 16d? | 443d |  |  | 24h |
| 130 | 7.2.4.1 | **Deploy** | 1d? | 2006-04-10 | 2006-04-10 | 128SS | 2006-04-03 | 2006-04-03 | 1d? | 453d |  | start no earlier than 2006-04-10 | 16h |
| 131 | 7.2.4.1.1 | EE | 1d? | 2006-04-10 | 2006-04-10 |  | 2006-04-03 | 2006-04-03 | 1d? | 453d |  |  | 8h |
| 132 | 7.2.4.1.2 | ME | 1d? | 2006-04-10 | 2006-04-10 |  | 2006-04-03 | 2006-04-03 | 1d? | 453d |  |  | 8h |
| 133 | 7.2.4.2 | **Recover** | 2d | 2006-04-21 | 2006-04-24 |  | 2006-04-21 | 2006-04-24 | 2d | 443d |  |  | 8h |
| 134 | 7.2.4.2.1 | EE | 2d | 2006-04-21 | 2006-04-24 | 128FF | 2006-04-21 | 2006-04-24 | 2d | 443d |  |  | 8h |
| 135 | 7.2.4.2.2 | ME | 2d | 2006-04-21 | 2006-04-24 | 128FF | 2006-04-21 | 2006-04-24 | 2d | 443d |  |  |  |
| 136 | 7.3 | **Deployment 3** | 10d? | 2006-05-01 | 2006-05-12 |  | 2006-01-04 | 2006-03-08 | 45d? | 429d |  |  | 24h |
| 137 | 7.3.1 | MOB | 1d | 2006-05-01 | 2006-05-01 | 140SS | 2006-01-04 | 2006-01-04 | 1d? | 438d | 0d | start no earlier than 2006-03-08 |  |
| 138 | 7.3.2 | **MOB resources** | 1d? | 2006-05-01 | 2006-05-01 | 137SS | 2006-05-01 | 2006-05-01 | 1d? | 438d |  |  | 8h |
| 139 | 7.3.2.1 | EE | 1d? | 2006-05-01 | 2006-05-01 |  | 2006-05-01 | 2006-05-01 | 1d? | 438d |  |  | 8h |
| 140 | 7.3.3 | Deployment | 10d | 2006-05-01 | 2006-05-12 |  | 2006-03-08 | 2006-03-08 | 10d | 429d | 0d | start no earlier than 2006-05-01 |  |
| 141 | 7.3.4 | **Deployment resources** | 10d? | 2006-05-01 | 2006-05-12 |  | 2006-05-01 | 2006-05-12 | 10d? | 429d |  |  | 16h |
| 142 | 7.3.4.1 | **Deploy** | 1d? | 2006-05-01 | 2006-05-01 | 140SS | 2006-05-01 | 2006-05-01 | 1d? | 438d |  |  | 8h |
| 143 | 7.3.4.1.1 | EE | 1d? | 2006-05-01 | 2006-05-01 |  | 2006-05-01 | 2006-05-01 | 1d? | 438d |  |  | 8h |

| ID | WBS | Task | Duration | Start | Finish | Predecessors | Baseline start | Baseline finish | Baseline duration | Total slack | Free slack | Constraint | Work |
| --- | --- | --- | --- | --- | --- | --- | --- | --- | --- | --- | --- | --- | --- |
| 144 | 7.3.4.2 | **Recover** | 2d | 2006-05-11 | 2006-05-12 |  | 2006-05-11 | 2006-05-12 | 2d | 429d |  |  | 8h |
| 145 | 7.3.4.2.1 | EE | 2d | 2006-05-11 | 2006-05-12 | 140FF | 2006-05-11 | 2006-05-12 | 2d | 429d |  |  | 8h |
| 146 | 7.4 | **Deployment 4** | 20d? | 2006-05-30 | 2006-06-26 |  | 2006-01-04 | 2006-03-08 | 45d? | 398d |  |  | 24h |
| 147 | 7.4.1 | MOB | 1d | 2006-05-30 | 2006-05-30 | 150SS | 2006-01-04 | 2006-01-04 | 1d? | 417d | 0d | start no earlier than 2006-03-08 |  |
| 148 | 7.4.2 | **MOB resources** | 1d? | 2006-05-30 | 2006-05-30 | 147SS | 2006-05-30 | 2006-05-30 | 1d? | 417d |  |  | 8h |
| 149 | 7.4.2.1 | EE | 1d? | 2006-05-30 | 2006-05-30 |  | 2006-05-30 | 2006-05-30 | 1d? | 417d |  |  | 8h |
| 150 | 7.4.3 | Deployment | 20d | 2006-05-30 | 2006-06-26 |  | 2006-03-08 | 2006-03-08 | 20d | 398d | 0d | start no earlier than 2006-05-30 |  |
| 151 | 7.4.4 | **Deployment resources** | 20d? | 2006-05-30 | 2006-06-26 |  | 2006-05-30 | 2006-06-26 | 20d? | 398d |  |  | 16h |
| 152 | 7.4.4.1 | **Deploy** | 1d? | 2006-05-30 | 2006-05-30 | 150SS | 2006-05-30 | 2006-05-30 | 1d? | 417d |  |  | 8h |
| 153 | 7.4.4.1.1 | EE | 1d? | 2006-05-30 | 2006-05-30 |  | 2006-05-30 | 2006-05-30 | 1d? | 417d |  |  | 8h |
| 154 | 7.4.4.2 | **Recover** | 2d | 2006-06-23 | 2006-06-26 |  | 2006-06-23 | 2006-06-26 | 2d | 398d |  |  | 8h |
| 155 | 7.4.4.2.1 | EE | 2d | 2006-06-23 | 2006-06-26 | 150FF | 2006-06-23 | 2006-06-26 | 2d | 398d |  |  | 8h |
| 156 | 7.5 | **Deployment 5** | 14d? | 2006-07-05 | 2006-07-24 |  | 2006-01-04 | 2006-03-08 | 45d? | 378d |  |  | 24h |
| 157 | 7.5.1 | MOB | 1d | 2006-07-05 | 2006-07-05 | 160SS | 2006-01-04 | 2006-01-04 | 1d? | 391d | 0d | start no earlier than 2006-03-08 |  |
| 158 | 7.5.2 | **MOB resources** | 1d? | 2006-07-05 | 2006-07-05 | 157SS | 2006-07-05 | 2006-07-05 | 1d? | 391d |  |  | 8h |
| 159 | 7.5.2.1 | EE | 1d? | 2006-07-05 | 2006-07-05 |  | 2006-07-05 | 2006-07-05 | 1d? | 391d |  |  | 8h |
| 160 | 7.5.3 | Deployment | 14d | 2006-07-05 | 2006-07-24 |  | 2006-03-08 | 2006-03-08 | 14d | 378d | 0d | start no earlier than 2006-07-05 |  |
| 161 | 7.5.4 | **Deployment resources** | 14d? | 2006-07-05 | 2006-07-24 |  | 2006-07-05 | 2006-07-24 | 14d? | 378d |  |  | 16h |
| 162 | 7.5.4.1 | **Deploy** | 1d? | 2006-07-05 | 2006-07-05 | 160SS | 2006-07-05 | 2006-07-05 | 1d? | 391d |  |  | 8h |
| 163 | 7.5.4.1.1 | EE | 1d? | 2006-07-05 | 2006-07-05 |  | 2006-07-05 | 2006-07-05 | 1d? | 391d |  |  | 8h |
| 164 | 7.5.4.2 | **Recover** | 2d | 2006-07-21 | 2006-07-24 |  | 2006-07-21 | 2006-07-24 | 2d | 378d |  |  | 8h |
| 165 | 7.5.4.2.1 | EE | 2d | 2006-07-21 | 2006-07-24 | 160FF | 2006-07-21 | 2006-07-24 | 2d | 378d |  |  | 8h |
| 166 | 7.6 | **Deployment 6** | 17d? | 2006-09-08 | 2006-10-02 |  | 2006-01-04 | 2006-03-08 | 45d? | 328d |  |  | 24h |
| 167 | 7.6.1 | MOB | 1d | 2006-09-08 | 2006-09-08 | 170SS | 2006-01-04 | 2006-01-04 | 1d? | 344d | 0d | start no earlier than 2006-03-08 |  |

| ID | WBS | Task | Type | Duration | Start | Finish | Predecessors | Remaining | Baseline start | Baseline finish | Baseline duration | Total slack | Free slack | Constraint | Deadline | Work | Actual work |
| --- | --- | --- | --- | --- | --- | --- | --- | --- | --- | --- | --- | --- | --- | --- | --- | --- | --- |
| 168 | 7.6.2 | **MOB resources** |  | 1d? | 2006-09-08 | 2006-09-08 | 167SS |  | 2006-09-08 | 2006-09-08 | 1d? | 344d |  |  |  | 8h |  |
| 169 | 7.6.2.1 | EE |  | 1d? | 2006-09-08 | 2006-09-08 |  |  | 2006-09-08 | 2006-09-08 | 1d? | 344d |  |  |  | 8h |  |
| 170 | 7.6.3 | Deployment |  | 17d | 2006-09-08 | 2006-10-02 |  |  | 2006-03-08 | 2006-03-08 | 17d | 328d | 0d | start no earlier than 2006-09-08 |  |  |  |
| 171 | 7.6.4 | **Deployment resources** |  | 17d? | 2006-09-08 | 2006-10-02 |  |  | 2006-09-08 | 2006-10-02 | 17d? | 328d |  |  |  | 16h |  |
| 172 | 7.6.4.1 | **Deploy** |  | 1d? | 2006-09-08 | 2006-09-08 | 170SS |  | 2006-09-08 | 2006-09-08 | 1d? | 344d |  |  |  | 8h |  |
| 173 | 7.6.4.1.1 | EE |  | 1d? | 2006-09-08 | 2006-09-08 |  |  | 2006-09-08 | 2006-09-08 | 1d? | 344d |  |  |  | 8h |  |
| 174 | 7.6.4.2 | **Recover** |  | 2d | 2006-09-29 | 2006-10-02 |  |  | 2006-09-29 | 2006-10-02 | 2d | 328d |  |  |  | 8h |  |
| 175 | 7.6.4.2.1 | EE |  | 2d | 2006-09-29 | 2006-10-02 | 170FF |  | 2006-09-29 | 2006-10-02 | 2d | 328d |  |  |  | 8h |  |
| 176 | 7.7 | **Deployment contingency** |  | 2d | 2006-09-29 | 2006-10-02 |  |  | 2006-09-29 | 2006-10-02 | 2d | 328d |  |  |  | 296h |  |
| 177 | 7.7.1 | EE |  | 2d | 2006-09-29 | 2006-10-02 | 111SS |  | 2006-09-29 | 2006-10-02 | 2d | 328d |  | finish no earlier than 2006-10-02 |  | 48h |  |
| 178 | 7.7.2 | ME |  | 2d | 2006-09-29 | 2006-10-02 | 111SS |  | 2006-09-29 | 2006-10-02 | 2d | 328d |  | finish no earlier than 2006-10-02 |  | 64h |  |
| 179 | 7.7.3 | SE |  | 2d | 2006-09-29 | 2006-10-02 | 111SS |  | 2006-09-29 | 2006-10-02 | 2d | 328d |  | finish no earlier than 2006-10-02 |  | 120h |  |
| 180 | 7.7.4 | ME Tech |  | 2d | 2006-09-29 | 2006-10-02 | 111SS |  | 2006-09-29 | 2006-10-02 | 2d | 328d |  | finish no earlier than 2006-10-02 |  | 40h |  |
| 181 | 7.7.5 | EE Tech |  | 2d | 2006-09-29 | 2006-10-02 | 111SS |  | 2006-09-29 | 2006-10-02 | 2d | 328d |  | finish no earlier than 2006-10-02 |  | 24h |  |
| 183 | 8 | **Tech xfer** |  | 236d? | 2006-01-04 A | 2006-11-29 |  | 235.22d? | 2006-01-04 | 2006-01-04 | 1d? | 286d |  |  |  | 2104h | 8h |
| 184 | 8.1 | **Build 3 copies using exisiting design and spec, based on GiGi working** |  | 236d? | 2006-01-04 A | 2006-11-29 |  | 235.22d? | 2006-01-04 | 2006-01-04 | 1d? | 286d |  |  |  | 2104h | 8h |
| 185 | 8.1.1 | **Pre-production** |  | 172d? | 2006-01-04 A | 2006-08-31 |  | 171.23d? |  |  |  | 350d |  |  |  | 960h | 8h |
| 186 | 8.1.1.1 | **system** |  | 1d? | 2006-01-04 | 2006-01-04 |  |  |  |  |  | 521d |  |  |  |  |  |
| 187 | 8.1.1.1.1 | Investigate BC Tech subcontracts |  | 1d? | 2006-01-04 | 2006-01-04 |  |  |  |  |  | 521d |  |  |  |  |  |
| 188 | 8.1.1.1.2 | Extending duration |  | 1d? | 2006-01-04 | 2006-01-04 |  |  |  |  |  | 521d |  |  |  |  |  |
| 189 | 8.1.1.2 | **Mechanical** |  | 48d? | 2006-01-04 | 2006-03-10 |  |  |  |  |  | 84d |  |  |  | 440h |  |
| 190 | 8.1.1.2.1 | Solid Works critical subassemblies |  | 1d? | 2006-01-04 | 2006-01-04 |  |  |  |  |  | 84d | 0d |  |  | 200h |  |
| 191 | 8.1.1.2.2 | Bid subassemblies |  | 1d? | 2006-01-05 | 2006-01-05 | 190 |  |  |  |  | 84d | 0d |  |  | 16h |  |
| 192 | 8.1.1.2.3 | Procure subassemblies |  | 1d? | 2006-01-06 | 2006-01-06 | 191 |  |  |  |  | 84d | 0d |  |  | 8h |  |
| 193 | 8.1.1.2.4 | Solid Works complete model & print package | milestone | 0d | 2006-01-06 | 2006-01-06 | 192 |  |  |  |  | 84d | 0d |  | 2006-05-04 |  |  |
| 194 | 8.1.1.2.5 | Bid print package |  | 10d | 2006-01-09 | 2006-01-20 | 193 |  |  |  |  | 508d | 0d |  |  | 8h |  |
| 195 | 8.1.1.2.6 | Cost estimate of COTS parts + sparse |  | 47d | 2006-01-04 | 2006-03-09 |  |  |  |  |  | 474d | 0d |  |  | 40h |  |
| 196 | 8.1.1.2.7 | Order machined parts |  | 1d? | 2006-01-23 | 2006-01-23 | 194 |  |  |  |  | 508d |  |  |  | 8h |  |
| 197 | 8.1.1.2.8 | Order COTS |  | 1d? | 2006-03-10 | 2006-03-10 | 195 |  |  |  |  | 474d |  |  |  | 80h |  |
| 198 | 8.1.1.2.9 | Parts Inventory & Organization |  | 1d? | 2006-03-10 | 2006-03-10 | 195 |  |  |  |  | 474d |  |  |  | 80h |  |

Notes:
- 194: RWI (Ron Witherspoon) in Castroville / Williamson

| ID | WBS | Task | Type | Duration | Start | Finish | Predecessors | Complete | Remaining | Baseline start | Baseline finish | Baseline duration | Total slack | Free slack | Constraint | Work | Actual work |
| --- | --- | --- | --- | --- | --- | --- | --- | --- | --- | --- | --- | --- | --- | --- | --- | --- | --- |
| 199 | 8.1.1.3 | **Electrical** |  | 172d? | 2006-01-04 A | 2006-08-31 |  | 2% | 168.98d? |  |  |  | 350d |  |  | 200h | 8h |
| 200 | 8.1.1.3.1 | Investigate subcontracting cabling |  | 15d | 2006-01-04 | 2006-01-24 |  |  |  |  |  |  | 507d |  |  | 40h |  |
| 201 | 8.1.1.3.2 | Investigate subcontracting boards |  | 5d | 2006-01-04 | 2006-01-10 |  |  |  |  |  |  | 517d |  |  | 8h |  |
| 202 | 8.1.1.3.3 | Schematics Verified |  | 5d | 2006-04-07 | 2006-04-13 |  |  |  |  |  |  | 448d | 0d | start no earlier than 2006-04-07 | 24h |  |
| 203 | 8.1.1.3.4 | Lab space & staging area |  | 2d? | 2006-01-04 A | 2006-01-05 |  | 50% | 1d? |  |  |  | 520d |  |  | 16h | 8h |
| 204 | 8.1.1.3.5 | Cost Estimate |  | 2d | 2006-04-14 | 2006-04-17 | 202 |  |  |  |  |  | 448d |  |  | 8h |  |
| 205 | 8.1.1.3.6 | Order Parts |  | 7d | 2006-04-18 | 2006-04-26 | 204 |  |  |  |  |  | 441d |  | start no earlier than 2006-04-10 | 24h |  |
| 206 | 8.1.1.3.7 | Part inventory & Organization |  | 20d | 2006-04-14 | 2006-05-11 | 202 |  |  | 2006-01-04 | 2006-01-04 | 1d? | 430d |  | start no earlier than 2006-04-03 | 40h |  |
| 207 | 8.1.1.3.8 | All EE Parts in House | milestone | 0d | 2006-08-31 | 2006-08-31 |  |  |  |  |  |  | 350d |  | finish no earlier than 2006-08-31 |  |  |
| 208 | 8.1.1.3.9 | Document Package |  | 1d? | 2006-01-04 | 2006-01-04 |  |  |  |  |  |  | 521d |  |  | 40h |  |
| 209 | 8.1.1.4 | **Software** |  | 81d? | 2006-01-04 | 2006-04-26 |  |  |  |  |  |  | 441d |  |  | 320h |  |
| 210 | 8.1.1.4.1 | Modularize scripting |  | 1d? | 2006-01-04 | 2006-01-04 |  |  |  |  |  |  | 521d |  |  | 40h |  |
| 211 | 8.1.1.4.2 | document all software |  | 40d | 2006-01-05 | 2006-03-01 | 210 |  |  |  |  |  | 441d | 0d |  | 80h |  |
| 212 | 8.1.1.4.3 | software user manual |  | 40d | 2006-03-02 | 2006-04-26 | 211 |  |  |  |  |  | 441d |  |  | 120h |  |
| 213 | 8.1.1.4.4 | Increase duration to 1 month |  | 20d | 2006-01-04 | 2006-01-31 |  |  |  |  |  |  | 502d |  |  | 80h |  |
| 214 | 8.1.2 | **Production** |  | 236d? | 2006-01-04 | 2006-11-29 |  |  |  |  |  |  | 286d |  |  | 1136h |  |
| 215 | 8.1.2.1 | **Documentation** |  | 1d? | 2006-01-04 | 2006-01-04 |  |  |  |  |  |  | 521d |  |  | 80h |  |
| 216 | 8.1.2.1.1 | Software user manual |  | 1d? | 2006-01-04 | 2006-01-04 |  |  |  |  |  |  | 521d |  |  | 80h |  |
| 217 | 8.1.2.2 | **Mechanical** |  | 236d? | 2006-01-04 | 2006-11-29 |  |  |  |  |  |  | 286d |  |  | 1008h |  |
| 218 | 8.1.2.2.1 | All COTS parts in house | milestone | 0d | 2006-08-31 | 2006-08-31 |  |  |  |  |  |  | 350d |  | finish no earlier than 2006-08-31 |  |  |
| 219 | 8.1.2.2.2 | All Fabricated parts in house | milestone | 0d | 2006-01-04 | 2006-01-04 |  |  |  |  |  |  | 522d |  |  |  |  |
| 220 | 8.1.2.2.3 | Camera Jig |  | 1d? | 2006-01-04 | 2006-01-04 |  |  |  |  |  |  | 521d |  |  | 24h |  |
| 221 | 8.1.2.2.4 | **Subassembly** |  | 38d | 2006-09-04 | 2006-10-25 |  |  |  |  |  |  | 286d |  | start no earlier than 2006-09-04 | 648h |  |
| 222 | 8.1.2.2.4.1 | Carosel |  | 2d | 2006-09-04 | 2006-09-05 |  |  |  |  |  |  | 286d | 0d |  | 40h |  |
| 223 | 8.1.2.2.4.2 | Carosel mounting/top plate |  | 2d | 2006-09-06 | 2006-09-07 | 222 |  |  |  |  |  | 286d | 0d |  | 24h |  |
| 224 | 8.1.2.2.4.3 | Syringes |  | 2d | 2006-09-08 | 2006-09-11 | 223 |  |  |  |  |  | 286d | 0d |  | 32h |  |
| 225 | 8.1.2.2.4.4 | Manipulator Mechanical |  | 2d | 2006-09-12 | 2006-09-13 | 224 |  |  |  |  |  | 286d | 0d |  | 40h |  |
| 226 | 8.1.2.2.4.5 | Clamps |  | 2d | 2006-09-14 | 2006-09-15 | 225 |  |  |  |  |  | 286d | 0d |  | 40h |  |
| 227 | 8.1.2.2.4.6 | Heater |  | 2d | 2006-09-18 | 2006-09-19 | 226 |  |  |  |  |  | 286d | 0d |  | 40h |  |
| 228 | 8.1.2.2.4.7 | Plate |  | 2d | 2006-09-20 | 2006-09-21 | 227 |  |  |  |  |  | 286d | 0d |  | 40h |  |
| 229 | 8.1.2.2.4.8 | Rotary Valves |  | 4d | 2006-09-22 | 2006-09-27 | 228 |  |  |  |  |  | 286d | 0d |  | 72h |  |
| 230 | 8.1.2.2.4.9 | Syringe and rotary valve |  | 1d | 2006-09-28 | 2006-09-28 | 229 |  |  |  |  |  | 286d | 0d |  | 8h |  |
| 231 | 8.1.2.2.4.10 | Series Valves |  | 2d | 2006-09-29 | 2006-10-02 | 230 |  |  |  |  |  | 286d | 0d |  | 24h |  |
| 232 | 8.1.2.2.4.11 | Camera |  | 2d | 2006-10-03 | 2006-10-04 | 231 |  |  |  |  |  | 286d | 0d |  | 32h |  |
| 233 | 8.1.2.2.4.12 | Camera power supply |  | 1d | 2006-10-05 | 2006-10-05 | 232 |  |  |  |  |  | 286d | 0d |  | 16h |  |
| 234 | 8.1.2.2.4.13 | Elevator |  | 2d | 2006-10-06 | 2006-10-09 | 233 |  |  |  |  |  | 286d | 0d |  | 24h |  |
| 235 | 8.1.2.2.4.14 | Dwarf assembly |  | 2d | 2006-10-10 | 2006-10-11 | 234 |  |  |  |  |  | 286d | 0d |  | 40h |  |
| 236 | 8.1.2.2.4.15 | Sleepy board mounting |  | 1d | 2006-10-12 | 2006-10-12 | 235 |  |  |  |  |  | 286d | 0d |  | 16h |  |
| 237 | 8.1.2.2.4.16 | Manipulator Final |  | 2d | 2006-10-13 | 2006-10-16 | 236 |  |  |  |  |  | 286d | 0d |  | 40h |  |
| 238 | 8.1.2.2.4.17 | Tube preparation and plumbing |  | 4d | 2006-10-17 | 2006-10-20 | 237 |  |  |  |  |  | 286d | 0d |  | 72h |  |
| 239 | 8.1.2.2.4.18 | Jensen spit tubes |  | 1d | 2006-10-23 | 2006-10-23 | 238 |  |  |  |  |  | 286d | 0d |  | 8h |  |
| 240 | 8.1.2.2.4.19 | Miscellaneous |  | 2d | 2006-10-24 | 2006-10-25 | 239 |  |  |  |  |  | 286d | 0d |  | 40h |  |
| 241 | 8.1.2.2.4.20 | Subassemblies complete | milestone | 0d | 2006-10-25 | 2006-10-25 | 240 |  |  |  |  |  | 286d | 0d |  |  |  |

| ID | WBS | Task | Type | Duration | Start | Finish | Predecessors | Total slack | Free slack | Work |
| --- | --- | --- | --- | --- | --- | --- | --- | --- | --- | --- |
| 242 | 8.1.2.2.5 | **Final Assembly** |  | 25d | 2006-10-26 | 2006-11-29 | 241 | 286d |  | 336h |
| 243 | 8.1.2.2.5.1 | Mounting plate on holder |  | 2d | 2006-10-26 | 2006-10-27 | 239 | 286d | 0d | 32h |
| 244 | 8.1.2.2.5.2 | heaters |  | 1d | 2006-10-30 | 2006-10-30 | 243 | 286d | 0d | 16h |
| 245 | 8.1.2.2.5.3 | Elevator |  | 1d | 2006-10-31 | 2006-10-31 | 244 | 286d | 0d | 16h |
| 246 | 8.1.2.2.5.4 | Clamps |  | 1d | 2006-11-01 | 2006-11-01 | 245 | 286d | 0d | 8h |
| 247 | 8.1.2.2.5.5 | Syringe and Rotary Valve |  | 1d | 2006-11-02 | 2006-11-02 | 246 | 286d | 0d | 8h |
| 248 | 8.1.2.2.5.6 | Rotary valves |  | 2d | 2006-11-03 | 2006-11-06 | 247 | 286d | 0d | 32h |
| 249 | 8.1.2.2.5.7 | Series valves |  | 1d | 2006-11-07 | 2006-11-07 | 248 | 286d | 0d | 8h |
| 250 | 8.1.2.2.5.8 | Plumbing iniitial |  | 2d | 2006-11-08 | 2006-11-09 | 249 | 286d | 0d | 32h |
| 251 | 8.1.2.2.5.9 | Camera |  | 1d | 2006-11-10 | 2006-11-10 | 250 | 286d | 0d | 8h |
| 252 | 8.1.2.2.5.10 | Manipulator |  | 1d | 2006-11-13 | 2006-11-13 | 251 | 286d | 0d | 8h |
| 253 | 8.1.2.2.5.11 | Garage |  | 1d | 2006-11-14 | 2006-11-14 | 252 | 286d | 0d | 8h |
| 254 | 8.1.2.2.5.12 | Dwarfs |  | 2d | 2006-11-15 | 2006-11-16 | 253 | 286d | 0d | 32h |
| 255 | 8.1.2.2.5.13 | Sleepy board |  | 1d | 2006-11-17 | 2006-11-17 | 254 | 286d | 0d | 8h |
| 256 | 8.1.2.2.5.14 | Wiring |  | 4d | 2006-11-20 | 2006-11-23 | 255 | 286d | 0d | 64h |
| 257 | 8.1.2.2.5.15 | Camera power supply |  | 1d | 2006-11-24 | 2006-11-24 | 256 | 286d | 0d | 16h |
| 258 | 8.1.2.2.5.16 | Waste container |  | 1d | 2006-11-27 | 2006-11-27 | 257 | 286d | 0d | 8h |
| 259 | 8.1.2.2.5.17 | Plumbing Final |  | 2d | 2006-11-28 | 2006-11-29 | 258 | 286d | 0d | 32h |
| 260 | 8.1.2.2.5.18 | Final assembly complete | milestone | 0d | 2006-11-29 | 2006-11-29 | 259 | 286d |  |  |
| 261 | 8.1.2.3 | **Software** |  | 1d? | 2006-01-04 | 2006-01-04 |  | 521d |  |  |
| 262 | 8.1.2.3.1 | Finalized CDs? |  | 1d? | 2006-01-04 | 2006-01-04 |  | 521d |  |  |
| 263 | 8.1.2.4 | **Electrical** |  | 1d? | 2006-01-04 | 2006-01-04 |  | 521d |  | 48h |
| 264 | 8.1.2.4.1 | Cabling |  | 1d? | 2006-01-04 | 2006-01-04 |  | 521d |  | 16h |
| 265 | 8.1.2.4.2 | Fabrication |  | 1d? | 2006-01-04 | 2006-01-04 |  | 521d |  | 16h |
| 266 | 8.1.2.4.3 | Existing board update |  | 1d? | 2006-01-04 | 2006-01-04 |  | 521d |  | 16h |

| ID | WBS | Task | Duration | Start | Finish | Predecessors | Complete | Remaining | Baseline start | Baseline finish | Baseline duration | Total slack | Free slack | Resources | Work |
| --- | --- | --- | --- | --- | --- | --- | --- | --- | --- | --- | --- | --- | --- | --- | --- |
| 267 | 8.1.3 | **Quality Assurance** | 1d? | 2006-01-04 | 2006-01-04 |  |  |  |  |  |  | 521d |  |  | 8h |
| 268 | 8.1.3.1 | Alignment | 1d? | 2006-01-04 | 2006-01-04 |  |  |  |  |  |  | 521d |  |  |  |
| 269 | 8.1.3.2 | Reagent Storage | 1d? | 2006-01-04 | 2006-01-04 |  |  |  |  |  |  | 521d |  |  | 8h |
| 270 | 8.1.3.3 | Initial Integration & Test | 1d? | 2006-01-04 | 2006-01-04 |  |  |  |  |  |  | 521d |  |  |  |
| 271 | 8.1.3.4 | Cold water test | 1d? | 2006-01-04 | 2006-01-04 |  |  |  |  |  |  | 521d |  |  |  |
| 272 | 8.1.3.5 | Tank test | 1d? | 2006-01-04 | 2006-01-04 |  |  |  |  |  |  | 521d |  |  |  |
| 273 | 8.1.3.6 | Rework | 1d? | 2006-01-04 | 2006-01-04 |  |  |  |  |  |  | 521d |  |  |  |
| 274 | 8.1.4 | **Support** | 1d? | 2006-01-04 | 2006-01-04 |  |  |  |  |  |  | 521d |  |  |  |
| 275 | 8.1.4.1 | Copy Resources | 1d? | 2006-01-04 | 2006-01-04 |  |  |  | 2006-01-04 | 2006-01-04 | 1d? | 521d |  |  |  |
| 276 | 8.1.4.2 | initial user workshop - prep for demo deployments in 07; joint proposals | 1d? | 2006-01-04 | 2006-01-04 |  |  |  | 2006-01-04 | 2006-01-04 | 1d? | 521d |  |  |  |
| 277 | 8.1.4.3 | workshop Resources | 1d? | 2006-01-04 | 2006-01-04 |  |  |  | 2006-12-04 | 2006-12-04 | 1d? | 521d |  |  |  |
| 279 | 9 | **Deep water GiGI** | 67d? | 2006-01-04 A | 2006-04-06 |  | 1% | 66.53d? | 2006-01-04 | 2006-01-04 | 1d? | 455d |  |  | 880h |
| 280 | 9.1 | **D-ESP system testing** | 67d? | 2006-01-04 A | 2006-04-06 |  | 1% | 66.35d? | 2006-01-04 | 2006-01-04 | 1d? | 455d |  |  | 320h |
| 281 | 9.1.1 | 2G ESP valves and syringes in test fixture - 4C target | 1d? | 2006-01-04 A | 2006-01-04 |  | 75% | 0.25d? | 2006-01-04 | 2006-01-04 | 1d? | 521d |  |  |  |
| 282 | 9.1.2 | **DWSM Benchtop I&T** | 50d | 2006-01-04 | 2006-03-14 |  |  |  | 2006-01-04 | 2006-03-14 | 50d | 455d | 0d |  | 152h |
| 283 | 9.1.2.1 | EE | 6d | 2006-01-04 | 2006-01-11 |  |  |  | 2006-01-04 | 2006-01-11 | 6d | 499d |  | Scott [50%] | 24h |
| 284 | 9.1.2.2 | ME | 9d | 2006-01-04 | 2006-01-16 |  |  |  | 2006-01-04 | 2006-01-16 | 9d | 496d |  | Mark Brown [33.3%] | 24h |
| 285 | 9.1.2.3 | SE | 10d | 2006-03-01 | 2006-03-14 | 63 |  |  | 2006-03-01 | 2006-03-14 | 10d | 455d |  | Brent | 80h |
| 286 | 9.1.2.4 | Shop | 10d | 2006-01-04 | 2006-01-17 |  |  |  | 2006-01-04 | 2006-01-17 | 10d | 495d |  |  | 24h |
| 287 | 9.1.3 | **DWSM Coldroom testing** | 4d | 2006-03-15 | 2006-03-20 | 282 |  |  | 2006-03-15 | 2006-03-20 | 4d | 455d | 0d |  | 40h |
| 288 | 9.1.3.1 | EE | 4d | 2006-03-15 | 2006-03-20 |  |  |  | 2006-03-15 | 2006-03-20 | 4d | 455d |  | Scott [50%] | 16h |
| 289 | 9.1.3.2 | ME | 4d | 2006-03-15 | 2006-03-20 |  |  |  | 2006-03-15 | 2006-03-20 | 4d | 455d |  |  | 16h |
| 290 | 9.1.3.3 | SE | 2d | 2006-03-15 | 2006-03-16 |  |  |  | 2006-03-15 | 2006-03-16 | 2d | 457d |  | Brent [50%] | 8h |
| 291 | 9.1.4 | **DWSM ROV test** | 9d | 2006-03-21 | 2006-03-31 | 287 |  |  | 2006-03-21 | 2006-03-31 | 9d | 455d | 0d |  | 64h |
| 292 | 9.1.4.1 | EE | 9d | 2006-03-21 | 2006-03-31 |  |  |  | 2006-03-21 | 2006-03-31 | 9d | 455d |  | Scott [33.3%] | 24h |
| 293 | 9.1.4.2 | ME | 6d | 2006-03-21 | 2006-03-28 |  |  |  | 2006-03-21 | 2006-03-28 | 6d | 458d |  |  | 24h |
| 294 | 9.1.4.3 | SE | 4d | 2006-03-21 | 2006-03-24 |  |  |  | 2006-03-21 | 2006-03-24 | 4d | 460d |  | Brent [50%] | 16h |

| ID | WBS | Task | Duration | Start | Finish | Predecessors | Baseline start | Baseline finish | Baseline duration | Total slack | Free slack | Resources | Work |
| --- | --- | --- | --- | --- | --- | --- | --- | --- | --- | --- | --- | --- | --- |
| 295 | 9.1.5 | **D-ESP Benchtop I&T** | 1d? | 2006-04-03 | 2006-04-03 | 291 | 2006-04-03 | 2006-04-03 | 1d? | 455d | 0d |  | 16h |
| 296 | 9.1.5.1 | EE | 1d? | 2006-04-03 | 2006-04-03 |  | 2006-04-03 | 2006-04-03 | 1d? | 455d |  | Scott | 8h |
| 297 | 9.1.5.2 | ME | 1d? | 2006-04-03 | 2006-04-03 |  | 2006-04-03 | 2006-04-03 | 1d? | 455d |  |  |  |
| 298 | 9.1.5.3 | SE | 1d? | 2006-04-03 | 2006-04-03 |  | 2006-04-03 | 2006-04-03 | 1d? | 455d |  | Brent | 8h |
| 299 | 9.1.6 | **D-ESP Coldroom testing** | 1d? | 2006-04-04 | 2006-04-04 | 295 | 2006-04-04 | 2006-04-04 | 1d? | 455d | 0d |  | 16h |
| 300 | 9.1.6.1 | EE | 1d? | 2006-04-04 | 2006-04-04 |  | 2006-04-04 | 2006-04-04 | 1d? | 455d |  | Scott | 8h |
| 301 | 9.1.6.2 | ME | 1d? | 2006-04-04 | 2006-04-04 |  | 2006-04-04 | 2006-04-04 | 1d? | 455d |  |  |  |
| 302 | 9.1.6.3 | SE | 1d? | 2006-04-04 | 2006-04-04 |  | 2006-04-04 | 2006-04-04 | 1d? | 455d |  | Brent | 8h |
| 303 | 9.1.7 | **D-ESP Tank Test** | 1d? | 2006-04-05 | 2006-04-05 | 299 | 2006-04-05 | 2006-04-05 | 1d? | 455d | 0d |  | 16h |
| 304 | 9.1.7.1 | EE | 1d? | 2006-04-05 | 2006-04-05 |  | 2006-04-05 | 2006-04-05 | 1d? | 455d |  | Scott | 8h |
| 305 | 9.1.7.2 | ME | 1d? | 2006-04-05 | 2006-04-05 |  | 2006-04-05 | 2006-04-05 | 1d? | 455d |  |  |  |
| 306 | 9.1.7.3 | SE | 1d? | 2006-04-05 | 2006-04-05 |  | 2006-04-05 | 2006-04-05 | 1d? | 455d |  | Brent | 8h |
| 307 | 9.1.8 | **D-ESP ROV test** | 1d? | 2006-04-06 | 2006-04-06 | 303 | 2006-04-06 | 2006-04-06 | 1d? | 455d |  |  | 16h |
| 308 | 9.1.8.1 | EE | 1d? | 2006-04-06 | 2006-04-06 |  | 2006-04-06 | 2006-04-06 | 1d? | 455d |  | Scott | 8h |
| 309 | 9.1.8.2 | ME | 1d? | 2006-04-06 | 2006-04-06 |  | 2006-04-06 | 2006-04-06 | 1d? | 455d |  |  |  |
| 310 | 9.1.8.3 | SE | 1d? | 2006-04-06 | 2006-04-06 |  | 2006-04-06 | 2006-04-06 | 1d? | 455d |  | Brent | 8h |
| 311 | 9.2 | **Deploy D-ESP on ROV - 2, 1day dives (2mobs)** | 1d? | 2006-01-04 | 2006-01-04 |  | 2006-01-04 | 2006-01-04 | 1d? | 521d |  |  | 80h |
| 312 | 9.2.1 | **Deployment 1** | 1d? | 2006-01-04 | 2006-01-04 |  | 2006-01-04 | 2006-01-04 | 1d? | 521d |  |  | 40h |
| 313 | 9.2.1.1 | MOB | 1d? | 2006-01-04 | 2006-01-04 |  | 2006-01-04 | 2006-01-04 | 1d? | 521d |  |  |  |
| 314 | 9.2.1.2 | **MOB resources** | 1d? | 2006-01-04 | 2006-01-04 |  | 2006-01-04 | 2006-01-04 | 1d? | 521d |  |  | 24h |
| 315 | 9.2.1.2.1 | EE | 1d? | 2006-01-04 | 2006-01-04 |  | 2006-01-04 | 2006-01-04 | 1d? | 521d |  |  | 8h |
| 316 | 9.2.1.2.2 | ME | 1d? | 2006-01-04 | 2006-01-04 |  | 2006-01-04 | 2006-01-04 | 1d? | 521d |  |  | 8h |
| 317 | 9.2.1.2.3 | ME Tech | 1d? | 2006-01-04 | 2006-01-04 |  | 2006-01-04 | 2006-01-04 | 1d? | 521d |  |  | 8h |
| 318 | 9.2.1.3 | **Deployment** | 1d? | 2006-01-04 | 2006-01-04 |  | 2006-01-04 | 2006-01-04 | 1d? | 521d |  |  | 16h |
| 319 | 9.2.1.3.1 | EE | 1d? | 2006-01-04 | 2006-01-04 |  | 2006-01-04 | 2006-01-04 | 1d? | 521d |  |  | 8h |
| 320 | 9.2.1.3.2 | ME | 1d? | 2006-01-04 | 2006-01-04 |  | 2006-01-04 | 2006-01-04 | 1d? | 521d |  |  | 8h |

| ID | WBS | Task | Duration | Start | Finish | Baseline start | Baseline finish | Baseline duration | Total slack | Work |
| --- | --- | --- | --- | --- | --- | --- | --- | --- | --- | --- |
| 321 | 9.2.2 | **Deployment 2** | 1d? | 2006-01-04 | 2006-01-04 | 2006-01-04 | 2006-01-04 | 1d? | 521d | 40h |
| 322 | 9.2.2.1 | MOB | 1d? | 2006-01-04 | 2006-01-04 | 2006-01-04 | 2006-01-04 | 1d? | 521d |  |
| 323 | 9.2.2.2 | **MOB resources** | 1d? | 2006-01-04 | 2006-01-04 | 2006-01-04 | 2006-01-04 | 1d? | 521d | 24h |
| 324 | 9.2.2.2.1 | EE | 1d? | 2006-01-04 | 2006-01-04 | 2006-01-04 | 2006-01-04 | 1d? | 521d | 8h |
| 325 | 9.2.2.2.2 | ME | 1d? | 2006-01-04 | 2006-01-04 | 2006-01-04 | 2006-01-04 | 1d? | 521d | 8h |
| 326 | 9.2.2.2.3 | ME Tech | 1d? | 2006-01-04 | 2006-01-04 | 2006-01-04 | 2006-01-04 | 1d? | 521d | 8h |
| 327 | 9.2.2.3 | **Deployment** | 1d? | 2006-01-04 | 2006-01-04 | 2006-01-04 | 2006-01-04 | 1d? | 521d | 16h |
| 328 | 9.2.2.3.1 | EE | 1d? | 2006-01-04 | 2006-01-04 | 2006-01-04 | 2006-01-04 | 1d? | 521d | 8h |
| 329 | 9.2.2.3.2 | ME | 1d? | 2006-01-04 | 2006-01-04 | 2006-01-04 | 2006-01-04 | 1d? | 521d | 8h |
| 330 | 9.3 | **MARS interface** | 1d? | 2006-01-04 | 2006-01-04 | 2006-01-04 | 2006-01-04 | 1d? | 521d | 344h |
| 331 | 9.3.1 | **Power Supply and Communication** | 1d? | 2006-01-04 | 2006-01-04 | 2006-01-04 | 2006-01-04 | 1d? | 521d | 240h |
| 332 | 9.3.1.1 | EE | 1d? | 2006-01-04 | 2006-01-04 | 2006-01-04 | 2006-01-04 | 1d? | 521d | 160h |
| 333 | 9.3.1.2 | ME | 1d? | 2006-01-04 | 2006-01-04 | 2006-01-04 | 2006-01-04 | 1d? | 521d | 16h |
| 334 | 9.3.1.3 | SE | 1d? | 2006-01-04 | 2006-01-04 | 2006-01-04 | 2006-01-04 | 1d? | 521d | 24h |
| 335 | 9.3.1.4 | ME Tech | 1d? | 2006-01-04 | 2006-01-04 | 2006-01-04 | 2006-01-04 | 1d? | 521d | 40h |
| 336 | 9.3.2 | **deployment structure** | 1d? | 2006-01-04 | 2006-01-04 | 2006-01-04 | 2006-01-04 | 1d? | 521d | 104h |
| 337 | 9.3.2.1 | ME | 1d? | 2006-01-04 | 2006-01-04 | 2006-01-04 | 2006-01-04 | 1d? | 521d | 24h |
| 338 | 9.3.2.2 | ME Tech | 1d? | 2006-01-04 | 2006-01-04 | 2006-01-04 | 2006-01-04 | 1d? | 521d | 40h |
| 339 | 9.3.2.3 | Shop | 1d? | 2006-01-04 | 2006-01-04 | 2006-01-04 | 2006-01-04 | 1d? | 521d | 40h |
| 340 | 9.4 | **MARS deployment** | 1d? | 2006-01-04 | 2006-01-04 | 2006-01-04 | 2006-01-04 | 1d? | 521d | 136h |
| 341 | 9.4.1 | **MOB** | 1d? | 2006-01-04 | 2006-01-04 | 2006-01-04 | 2006-01-04 | 1d? | 521d | 72h |
| 342 | 9.4.1.1 | EE | 1d? | 2006-01-04 | 2006-01-04 | 2006-01-04 | 2006-01-04 | 1d? | 521d | 24h |
| 343 | 9.4.1.2 | ME | 1d? | 2006-01-04 | 2006-01-04 | 2006-01-04 | 2006-01-04 | 1d? | 521d | 8h |
| 344 | 9.4.1.3 | SE | 1d? | 2006-01-04 | 2006-01-04 | 2006-01-04 | 2006-01-04 | 1d? | 521d |  |
| 345 | 9.4.1.4 | ME Tech | 1d? | 2006-01-04 | 2006-01-04 | 2006-01-04 | 2006-01-04 | 1d? | 521d | 40h |
| 346 | 9.4.1.5 | EE Tech | 1d? | 2006-01-04 | 2006-01-04 | 2006-01-04 | 2006-01-04 | 1d? | 521d |  |
| 347 | 9.4.1.6 | Shop | 1d? | 2006-01-04 | 2006-01-04 | 2006-01-04 | 2006-01-04 | 1d? | 521d |  |

| ID | WBS | Task | Duration | Start | Finish | Predecessors | Baseline start | Baseline finish | Baseline duration | Total slack | Free slack | Constraint | Deadline | Work |
| --- | --- | --- | --- | --- | --- | --- | --- | --- | --- | --- | --- | --- | --- | --- |
| 348 | 9.4.2 | **contingency/support** | 1d? | 2006-01-04 | 2006-01-04 |  | 2006-01-04 | 2006-01-04 | 1d? | 521d |  |  |  | 64h |
| 349 | 9.4.2.1 | EE | 1d? | 2006-01-04 | 2006-01-04 |  | 2006-01-04 | 2006-01-04 | 1d? | 521d |  |  |  | 8h |
| 350 | 9.4.2.2 | ME | 1d? | 2006-01-04 | 2006-01-04 |  | 2006-01-04 | 2006-01-04 | 1d? | 521d |  |  |  | 8h |
| 351 | 9.4.2.3 | SE | 1d? | 2006-01-04 | 2006-01-04 |  | 2006-01-04 | 2006-01-04 | 1d? | 521d |  |  |  | 24h |
| 352 | 9.4.2.4 | ME Tech | 1d? | 2006-01-04 | 2006-01-04 |  | 2006-01-04 | 2006-01-04 | 1d? | 521d |  |  |  | 24h |
| 353 | 9.4.2.5 | EE Tech | 1d? | 2006-01-04 | 2006-01-04 |  | 2006-01-04 | 2006-01-04 | 1d? | 521d |  |  |  |  |
| 354 | 9.4.2.6 | Shop | 1d? | 2006-01-04 | 2006-01-04 |  | 2006-01-04 | 2006-01-04 | 1d? | 521d |  |  |  |  |
| 356 | 10 | **NASA ASTEP** | 254d? | 2006-01-04 | 2006-12-25 |  | 2006-01-04 | 2006-01-04 | 1d? | 63d |  |  |  | 3480h |
| 357 | 10.1 | Meeting review | 2d? | 2006-02-24 | 2006-02-27 |  | 2006-02-24 | 2006-02-24 | 1d? | 482d | 0d | finish no earlier than 2006-02-27 |  |  |
| 358 | 10.2 | Kick off meeting | 1d? | 2006-02-28 | 2006-02-28 | 357 | 2006-02-28 | 2006-02-28 | 1d? | 482d |  | start no earlier than 2006-02-28 |  |  |
| 359 | 10.3 | **System Specification** | 85d? | 2006-01-04 | 2006-05-02 |  | 2006-01-04 | 2006-01-04 | 1d? | 63d |  |  |  | 48h |
| 360 | 10.3.1 | **LLNL I.C.D. Specifications** | 22d | 2006-04-03 | 2006-05-02 |  |  |  |  | 0d |  | start no earlier than 2006-04-03 |  | 48h |
| 361 | 10.3.1.1 | PCR Module Mechanical & Electrical | 22d | 2006-04-03 | 2006-05-02 |  |  |  |  | 0d |  |  | 2006-05-02 | 8h |
| 362 | 10.3.1.2 | Command Control Interface | 22d | 2006-04-03 | 2006-05-02 |  |  |  |  | 437d |  |  |  | 8h |
| 363 | 10.3.1.3 | Thermal Interface | 22d | 2006-04-03 | 2006-05-02 |  |  |  |  | 437d |  |  |  | 8h |
| 364 | 10.3.1.4 | Fluidic Interface | 22d | 2006-04-03 | 2006-05-02 |  |  |  |  | 437d |  |  |  | 8h |
| 365 | 10.3.1.5 | Data Processing | 22d | 2006-04-03 | 2006-05-02 |  |  |  |  | 437d |  |  |  | 8h |
| 366 | 10.3.1.6 | Generic Protocol | 22d | 2006-04-03 | 2006-05-02 |  |  |  |  | 437d |  |  |  | 8h |
| 367 | 10.3.2 | **MBARI Engineering I.C.D. Specifications** | 1d? | 2006-01-04 | 2006-01-04 |  |  |  |  | 521d |  |  |  |  |
| 368 | 10.3.2.1 | Electrical | 1d? | 2006-01-04 | 2006-01-04 |  |  |  |  | 521d |  |  |  |  |
| 369 | 10.3.2.2 | Software | 1d? | 2006-01-04 | 2006-01-04 |  |  |  |  | 521d |  |  |  |  |
| 370 | 10.3.2.3 | Thermal Interface | 1d? | 2006-01-04 | 2006-01-04 |  |  |  |  | 521d |  |  |  |  |
| 371 | 10.3.2.4 | Mechanical | 1d? | 2006-01-04 | 2006-01-04 |  |  |  |  | 521d |  |  |  |  |
| 372 | 10.3.2.5 | Sci | 1d? | 2006-01-04 | 2006-01-04 |  | 2006-01-04 | 2006-01-04 | 1d? | 521d |  |  |  |  |

Notes:
- 361: Need power curves, we will provide fixed voltages.
- 362: Need list of commands. / LLNL will support I2C and RS232 buses
- 363: Currently LLNL uses a fan for cooling. / Need to understand thermal control cycles. / May need to investigate thermal electric cooler.
- 364: I/O Fittings / Sample tube spec. / fluid schematic for PCR
- 365: Outputs from LLNL's module: / raw data curve / cycle thresholds / Also need trouble shooting flow chart
- 367: Does not include DWSM
- 368: Need to list available power and voltages for LLNL. / Need to document dwarf board and supporting docs.
- 370: MBARI needs to specify ambient temperature range / (possibly 4 - 35 degree C)
- 371: Acceleration ranges (3/4 G to 1.0 G) / What is the angle of orientation during nominal ops

| ID | WBS | Task | Duration | Start | Finish | Predecessors | Total slack | Free slack | Constraint | Work |
| --- | --- | --- | --- | --- | --- | --- | --- | --- | --- | --- |
| 373 | 10.3.3 | **MBARI Science Specs** | 1d? | 2006-01-04 | 2006-01-04 |  | 521d |  |  |  |
| 374 | 10.3.3.1 | Sampling spec. | 1d? | 2006-01-04 | 2006-01-04 |  | 521d |  |  |  |
| 375 | 10.3.3.2 | Sample Inventory | 1d? | 2006-01-04 | 2006-01-04 |  | 521d |  |  |  |
| 376 | 10.3.3.3 | Identify cruises of opportunity | 1d? | 2006-01-04 | 2006-01-04 |  | 521d |  |  |  |
| 377 | 10.3.3.4 | Identify suite of contextual sensors | 1d? | 2006-01-04 | 2006-01-04 |  | 521d |  |  |  |
| 378 | 10.3.3.5 | Develop detailed use case scenarios | 1d? | 2006-01-04 | 2006-01-04 |  | 521d |  |  |  |
| 379 | 10.4 | **Assay Development** | 1d? | 2006-01-04 | 2006-01-04 |  | 521d |  |  |  |
| 380 | 10.4.1 | SH Assay Development & Testing | 1d? | 2006-01-04 | 2006-01-04 |  | 521d |  |  |  |
| 381 | 10.4.2 | PCR Assay Development & Testing | 1d? | 2006-01-04 | 2006-01-04 |  | 521d |  |  |  |
| 382 | 10.4.3 | Probe validation and calibration | 1d? | 2006-01-04 | 2006-01-04 |  | 521d |  |  |  |
| 383 | 10.4.4 | Identify possible positive control | 1d? | 2006-01-04 | 2006-01-04 |  | 521d |  |  |  |
| 384 | 10.4.5 | Reagent stability test | 1d? | 2006-01-04 | 2006-01-04 |  | 521d |  |  |  |
| 385 | 10.4.6 | Bench comparison w/ realistic sample volume | 1d? | 2006-01-04 | 2006-01-04 |  | 521d |  |  |  |
| 386 | 10.4.7 | Run hybrid on bench, test with cold | 1d? | 2006-01-04 | 2006-01-04 |  | 521d |  |  |  |
| 387 | 10.5 | **Science Test** | 1d? | 2006-01-04 | 2006-01-04 |  | 521d |  |  |  |
| 388 | 10.5.1 | ESP lab test (existing unit) | 1d? | 2006-01-04 | 2006-01-04 |  | 521d |  |  |  |
| 389 | 10.5.2 | ESP Lab test (ASTEP dedicated unit) | 1d? | 2006-01-04 | 2006-01-04 |  | 521d |  |  |  |
| 390 | 10.5.3 | Presentation and publications | 1d? | 2006-01-04 | 2006-01-04 |  | 521d |  |  |  |
| 392 | 10.6 | **DWSM 1G (1KM)** | 254d? | 2006-01-04 | 2006-12-25 |  | 268d |  |  | 1592h |
| 393 | 10.6.1 | **System** | 78d | 2006-01-04 | 2006-04-21 |  | 444d |  |  | 88h |
| 394 | 10.6.1.1 | System requires & concept doc. | 15d | 2006-04-03 | 2006-04-21 |  | 444d |  | start no earlier than 2006-04-03 | 8h |
| 395 | 10.6.1.2 | ?????Test fixture development???? | 20d | 2006-01-04 | 2006-01-31 |  | 502d |  |  | 80h |
| 396 | 10.6.2 | **Mechancial** | 56d | 2006-04-17 | 2006-07-03 |  | 393d |  |  | 232h |
| 397 | 10.6.2.1 | Pressure test of Deep water housing Port Hueneme | 7d | 2006-04-17 | 2006-04-25 |  | 431d | 0d | start no earlier than 2006-04-17 | 40h |
| 398 | 10.6.2.2 | Mechanical Assembly | 8d | 2006-04-26 | 2006-05-05 | 397 | 431d | 0d |  | 16h |
| 399 | 10.6.2.3 | Final Assembly | 3d | 2006-05-08 | 2006-05-10 | 398 | 431d |  |  | 8h |
| 400 | 10.6.2.4 | Modified bracket designed & fabricated | 21d | 2006-04-17 | 2006-05-15 |  | 393d | 0d | start no earlier than 2006-04-17 | 40h |
| 401 | 10.6.2.5 | Design toolsled interface | 20d | 2006-05-16 | 2006-06-12 | 400 | 393d | 0d |  | 80h |
| 402 | 10.6.2.6 | Fabricate toolsled interface | 15d | 2006-06-13 | 2006-07-03 | 401 | 393d |  |  | 48h |

Notes:
- 374: volume requirements / pre-filtering requirements
- 395: Clamp with puck

| ID | WBS | Task | Duration | Start | Finish | Predecessors | Total slack | Free slack | Constraint | Work |
| --- | --- | --- | --- | --- | --- | --- | --- | --- | --- | --- |
| 403 | 10.6.3 | **Electrical** | 53d | 2006-04-17 | 2006-06-28 |  | 396d |  |  | 120h |
| 404 | 10.6.3.1 | Analog pressure to Elmo controller | 15d | 2006-04-17 | 2006-05-05 |  | 396d | 0d | start no earlier than 2006-04-17 | 80h |
| 405 | 10.6.3.2 | Connectors? | 3d | 2006-05-08 | 2006-05-10 | 404 | 396d | 0d |  | 8h |
| 406 | 10.6.3.3 | Cabling spec & procure | 30d | 2006-05-11 | 2006-06-21 | 405 | 396d | 0d |  | 24h |
| 407 | 10.6.3.4 | Cabling of pressure to Elmo | 5d | 2006-06-22 | 2006-06-28 | 406 | 396d |  |  | 8h |
| 408 | 10.6.4 | **Software** | 141d? | 2006-03-27 | 2006-10-09 |  | 283d |  | start no earlier than 2006-03-27 | 608h |
| 409 | 10.6.4.1 | System Model Development | 20d | 2006-04-17 | 2006-05-12 |  | 268d | 0d | start no earlier than 2006-04-17 | 80h |
| 410 | 10.6.4.2 | Analysis & Design of Control Algorithm | 50d | 2006-05-15 | 2006-07-21 | 409 | 268d | 0d |  | 248h |
| 411 | 10.6.4.3 | Software development | 30d | 2006-07-24 | 2006-09-01 | 410 | 268d | 0d |  | 120h |
| 412 | 10.6.4.4 | Analysis at varying depths | 1d? | 2006-09-04 | 2006-09-04 | 411 | 268d | 0d |  |  |
| 413 | 10.6.4.5 | Test & Integration | 20d | 2006-09-05 | 2006-10-02 | 412 | 268d | 0d |  | 80h |
| 414 | 10.6.4.6 | Protocol development | 5d | 2006-10-03 | 2006-10-09 | 413 | 268d | 0d |  | 40h |
| 415 | 10.6.4.7 | Protocols implementation | 10d | 2006-03-27 | 2006-04-07 |  | 454d |  |  | 40h |
| 416 | 10.6.5 | **Integration** | 55d? | 2006-10-10 | 2006-12-25 | 414 | 268d |  |  | 544h |
| 417 | 10.6.5.1 | Test Plan Doc. | 4d | 2006-10-10 | 2006-10-13 |  | 268d | 0d |  | 16h |
| 418 | 10.6.5.2 | Manual Bench top test (straight pipe) | 8d | 2006-10-16 | 2006-10-25 | 417 | 268d | 0d |  | 32h |
| 419 | 10.6.5.3 | Science protocol development | 15d | 2006-10-26 | 2006-11-15 | 418 | 268d | 0d |  | 40h |
| 420 | 10.6.5.4 | Move onto PT. Lobos | 1d | 2006-11-16 | 2006-11-16 | 419 | 268d | 0d |  | 8h |
| 421 | 10.6.5.5 | ROV Test (straight pipe) | 3d | 2006-11-17 | 2006-11-21 | 420 | 268d | 0d |  | 8h |
| 422 | 10.6.5.6 | Bench Test using sampling protocol | 5d | 2006-11-22 | 2006-11-28 | 421 | 268d | 0d |  | 40h |
| 423 | 10.6.5.7 | Response to test | 7d | 2006-11-29 | 2006-12-07 | 422 | 268d | 0d |  | 40h |
| 424 | 10.6.5.8 | Bench test with ESP test fixture | 1d? | 2006-12-08 | 2006-12-08 | 423 | 268d | 0d |  | 80h |
| 425 | 10.6.5.9 | ROV Test with test fixture? | 1d? | 2006-12-11 | 2006-12-11 | 424 | 268d | 0d |  | 80h |
| 426 | 10.6.5.10 | Bench test with Instrument | 1d? | 2006-12-12 | 2006-12-12 | 425 | 268d | 0d |  | 80h |
| 427 | 10.6.5.11 | ROV Test with ESP | 1d? | 2006-12-13 | 2006-12-13 | 426 | 268d | 0d |  | 80h |

Notes:
- 417: Need failsafe in case of control system failure so as not to over pressurize ESP. / Purposely fail operation with straight pipe

| ID | WBS | Task | Duration | Start | Finish | Total slack |
| --- | --- | --- | --- | --- | --- | --- |
| 430 | 10.7 | **Fluidic Interface to PCR module** | 1d? | 2006-01-04 | 2006-01-04 | 521d |
| 431 | 10.7.1 | **System** | 1d? | 2006-01-04 | 2006-01-04 | 521d |
| 432 | 10.7.1.1 | Requirements Document | 1d? | 2006-01-04 | 2006-01-04 | 521d |
| 433 | 10.7.1.2 | Redesign of Core | 1d? | 2006-01-04 | 2006-01-04 | 521d |
| 434 | 10.7.1.3 | Assembly | 1d? | 2006-01-04 | 2006-01-04 | 521d |
| 435 | 10.7.2 | **Electrical** | 1d? | 2006-01-04 | 2006-01-04 | 521d |
| 436 | 10.7.2.1 | Design | 1d? | 2006-01-04 | 2006-01-04 | 521d |
| 437 | 10.7.2.2 | Procurement | 1d? | 2006-01-04 | 2006-01-04 | 521d |
| 438 | 10.7.2.3 | Fabrication | 1d? | 2006-01-04 | 2006-01-04 | 521d |
| 439 | 10.7.2.4 | Testing | 1d? | 2006-01-04 | 2006-01-04 | 521d |
| 440 | 10.7.3 | **Mechanical** | 1d? | 2006-01-04 | 2006-01-04 | 521d |
| 441 | 10.7.3.1 | Design | 1d? | 2006-01-04 | 2006-01-04 | 521d |
| 442 | 10.7.3.2 | Procurement | 1d? | 2006-01-04 | 2006-01-04 | 521d |
| 443 | 10.7.3.3 | Fabrication | 1d? | 2006-01-04 | 2006-01-04 | 521d |
| 444 | 10.7.3.4 | Testing | 1d? | 2006-01-04 | 2006-01-04 | 521d |
| 445 | 10.7.4 | **Software** | 1d? | 2006-01-04 | 2006-01-04 | 521d |
| 446 | 10.7.4.1 | Design | 1d? | 2006-01-04 | 2006-01-04 | 521d |
| 447 | 10.7.4.2 | Procurement | 1d? | 2006-01-04 | 2006-01-04 | 521d |
| 448 | 10.7.4.3 | Development | 1d? | 2006-01-04 | 2006-01-04 | 521d |
| 449 | 10.7.4.4 | Testing | 1d? | 2006-01-04 | 2006-01-04 | 521d |
| 450 | 10.7.5 | **Integration & Testing** | 1d? | 2006-01-04 | 2006-01-04 | 521d |
| 451 | 10.7.5.1 | Software Control | 1d? | 2006-01-04 | 2006-01-04 | 521d |
| 452 | 10.7.5.2 | Testing in House | 1d? | 2006-01-04 | 2006-01-04 | 521d |
| 453 | 10.7.5.3 | Testing with PCR | 1d? | 2006-01-04 | 2006-01-04 | 521d |
| 454 | 10.7.5.4 | Integration into Core | 1d? | 2006-01-04 | 2006-01-04 | 521d |
| 455 | 10.7.5.5 | Testing System | 1d? | 2006-01-04 | 2006-01-04 | 521d |

| ID | WBS | Task | Duration | Start | Finish | Baseline start | Baseline finish | Baseline duration | Total slack | Work |
| --- | --- | --- | --- | --- | --- | --- | --- | --- | --- | --- |
| 456 | 10.8 | **ISUS context sensor incorp** | 1d? | 2006-01-04 | 2006-01-04 | 2006-01-04 | 2006-01-04 | 1d? | 521d | 1840h |
| 457 | 10.8.1 | Sci | 1d? | 2006-01-04 | 2006-01-04 | 2006-01-04 | 2006-01-04 | 1d? | 521d |  |
| 458 | 10.8.2 | Sci Tech | 1d? | 2006-01-04 | 2006-01-04 | 2006-01-04 | 2006-01-04 | 1d? | 521d |  |
| 459 | 10.8.3 | EE | 1d? | 2006-01-04 | 2006-01-04 | 2006-01-04 | 2006-01-04 | 1d? | 521d | 16h |
| 460 | 10.8.4 | ME | 1d? | 2006-01-04 | 2006-01-04 | 2006-01-04 | 2006-01-04 | 1d? | 521d | 24h |
| 461 | 10.8.5 | SE | 1d? | 2006-01-04 | 2006-01-04 | 2006-01-04 | 2006-01-04 | 1d? | 521d | 80h |
| 462 | 10.8.6 | **modify/fab DWSM** | 1d? | 2006-01-04 | 2006-01-04 | 2006-01-04 | 2006-01-04 | 1d? | 521d | 440h |
| 463 | 10.8.6.1 | Sci | 1d? | 2006-01-04 | 2006-01-04 | 2006-01-04 | 2006-01-04 | 1d? | 521d |  |
| 464 | 10.8.6.2 | Sci Tech | 1d? | 2006-01-04 | 2006-01-04 | 2006-01-04 | 2006-01-04 | 1d? | 521d |  |
| 465 | 10.8.6.3 | EE | 1d? | 2006-01-04 | 2006-01-04 | 2006-01-04 | 2006-01-04 | 1d? | 521d | 160h |
| 466 | 10.8.6.4 | ME | 1d? | 2006-01-04 | 2006-01-04 | 2006-01-04 | 2006-01-04 | 1d? | 521d | 80h |
| 467 | 10.8.6.5 | SE | 1d? | 2006-01-04 | 2006-01-04 | 2006-01-04 | 2006-01-04 | 1d? | 521d | 40h |
| 468 | 10.8.6.6 | ME Tech | 1d? | 2006-01-04 | 2006-01-04 | 2006-01-04 | 2006-01-04 | 1d? | 521d | 80h |
| 469 | 10.8.6.7 | Shop | 1d? | 2006-01-04 | 2006-01-04 | 2006-01-04 | 2006-01-04 | 1d? | 521d | 80h |
| 470 | 10.8.7 | **Modify/fab 2G** | 1d? | 2006-01-04 | 2006-01-04 | 2006-01-04 | 2006-01-04 | 1d? | 521d | 720h |
| 471 | 10.8.7.1 | Sci | 1d? | 2006-01-04 | 2006-01-04 | 2006-01-04 | 2006-01-04 | 1d? | 521d |  |
| 472 | 10.8.7.2 | Sci Tech | 1d? | 2006-01-04 | 2006-01-04 | 2006-01-04 | 2006-01-04 | 1d? | 521d |  |
| 473 | 10.8.7.3 | EE | 1d? | 2006-01-04 | 2006-01-04 | 2006-01-04 | 2006-01-04 | 1d? | 521d | 160h |
| 474 | 10.8.7.4 | ME | 1d? | 2006-01-04 | 2006-01-04 | 2006-01-04 | 2006-01-04 | 1d? | 521d | 80h |
| 475 | 10.8.7.5 | SE | 1d? | 2006-01-04 | 2006-01-04 | 2006-01-04 | 2006-01-04 | 1d? | 521d | 80h |
| 476 | 10.8.7.6 | ME Tech | 1d? | 2006-01-04 | 2006-01-04 | 2006-01-04 | 2006-01-04 | 1d? | 521d | 160h |
| 477 | 10.8.7.7 | EE Tech | 1d? | 2006-01-04 | 2006-01-04 | 2006-01-04 | 2006-01-04 | 1d? | 521d | 80h |
| 478 | 10.8.7.8 | Shop | 1d? | 2006-01-04 | 2006-01-04 | 2006-01-04 | 2006-01-04 | 1d? | 521d | 160h |
| 479 | 10.8.8 | **design/fab pressure housing** | 1d? | 2006-01-04 | 2006-01-04 | 2006-01-04 | 2006-01-04 | 1d? | 521d | 320h |
| 480 | 10.8.8.1 | Sci | 1d? | 2006-01-04 | 2006-01-04 | 2006-01-04 | 2006-01-04 | 1d? | 521d |  |
| 481 | 10.8.8.2 | Sci Tech | 1d? | 2006-01-04 | 2006-01-04 | 2006-01-04 | 2006-01-04 | 1d? | 521d |  |
| 482 | 10.8.8.3 | EE | 1d? | 2006-01-04 | 2006-01-04 | 2006-01-04 | 2006-01-04 | 1d? | 521d | 40h |
| 483 | 10.8.8.4 | ME | 1d? | 2006-01-04 | 2006-01-04 | 2006-01-04 | 2006-01-04 | 1d? | 521d | 80h |
| 484 | 10.8.8.5 | ME Tech | 1d? | 2006-01-04 | 2006-01-04 | 2006-01-04 | 2006-01-04 | 1d? | 521d | 80h |
| 485 | 10.8.8.6 | EE Tech | 1d? | 2006-01-04 | 2006-01-04 | 2006-01-04 | 2006-01-04 | 1d? | 521d | 40h |
| 486 | 10.8.8.7 | Shop | 1d? | 2006-01-04 | 2006-01-04 | 2006-01-04 | 2006-01-04 | 1d? | 521d | 80h |

| ID | WBS | Task | Duration | Start | Finish | Baseline start | Baseline finish | Baseline duration | Total slack | Work |
| --- | --- | --- | --- | --- | --- | --- | --- | --- | --- | --- |
| 487 | 10.8.9 | **design/fab benthic mooring structure** | 1d? | 2006-01-04 | 2006-01-04 | 2006-01-04 | 2006-01-04 | 1d? | 521d | 240h |
| 488 | 10.8.9.1 | Sci | 1d? | 2006-01-04 | 2006-01-04 | 2006-01-04 | 2006-01-04 | 1d? | 521d |  |
| 489 | 10.8.9.2 | Sci Tech | 1d? | 2006-01-04 | 2006-01-04 | 2006-01-04 | 2006-01-04 | 1d? | 521d |  |
| 490 | 10.8.9.3 | EE | 1d? | 2006-01-04 | 2006-01-04 | 2006-01-04 | 2006-01-04 | 1d? | 521d | 40h |
| 491 | 10.8.9.4 | ME | 1d? | 2006-01-04 | 2006-01-04 | 2006-01-04 | 2006-01-04 | 1d? | 521d | 40h |
| 492 | 10.8.9.5 | ME Tech | 1d? | 2006-01-04 | 2006-01-04 | 2006-01-04 | 2006-01-04 | 1d? | 521d | 80h |
| 493 | 10.8.9.6 | EE Tech | 1d? | 2006-01-04 | 2006-01-04 | 2006-01-04 | 2006-01-04 | 1d? | 521d | 40h |
| 494 | 10.8.9.7 | Shop | 1d? | 2006-01-04 | 2006-01-04 | 2006-01-04 | 2006-01-04 | 1d? | 521d | 40h |
| 495 | 10.8.9.8 | Integration/testing/calibration | 1d? | 2006-01-04 | 2006-01-04 |  |  |  | 521d |  |
| 496 | 10.8.9.9 | MARS/MOOS interface | 1d? | 2006-01-04 | 2006-01-04 |  |  |  | 521d |  |
| 497 | 10.8.9.10 | Support | 1d? | 2006-01-04 | 2006-01-04 |  |  |  | 521d |  |
| 498 | 10.8.9.11 | Astrobiology Design Europa | 1d? | 2006-01-04 | 2006-01-04 |  |  |  | 521d |  |
| 499 | 10.8.10 | **Operations** | 1d? | 2006-01-04 | 2006-01-04 | 2006-01-04 | 2006-01-04 | 1d? | 521d |  |
| 500 | 10.8.10.1 | ROV Engineering test deployments | 1d? | 2006-01-04 | 2006-01-04 | 2006-01-04 | 2006-01-04 | 1d? | 521d |  |
| 501 | 10.8.10.2 | ROV science: SB Basin | 1d? | 2006-01-04 | 2006-01-04 | 2006-01-04 | 2006-01-04 | 1d? | 521d |  |
| 502 | 10.8.10.3 | ROV Science: G of Calif. | 1d? | 2006-01-04 | 2006-01-04 | 2006-01-04 | 2006-01-04 | 1d? | 521d |  |
| 503 | 10.8.10.4 | MARS/MOOS eng/sci testing Mont. Bay | 1d? | 2006-01-04 | 2006-01-04 | 2006-01-04 | 2006-01-04 | 1d? | 521d |  |
| 504 | 10.8.10.5 | Benthic mooring deployment: SB Basin | 1d? | 2006-01-04 | 2006-01-04 | 2006-01-04 | 2006-01-04 | 1d? | 521d |  |
| 505 | 10.8.10.6 | Benthic Mooring Deployment: J. de Fuca | 1d? | 2006-01-04 | 2006-01-04 | 2006-01-04 | 2006-01-04 | 1d? | 521d |  |
| 506 | 10.8.10.7 | Ship/FOV of opportunity: J. de Fuca | 1d? | 2006-01-04 | 2006-01-04 | 2006-01-04 | 2006-01-04 | 1d? | 521d |  |
| 508 | 11 | **Moore Foundation** | 522d? | 2006-01-04 | 2008-01-03 | 2006-01-04 | 2006-01-04 | 1d? | 0d | 1208h |
| 509 | 11.1 | **define functional requirements** | 1d? | 2006-01-04 | 2006-01-04 | 2006-01-04 | 2006-01-04 | 1d? | 521d |  |
| 510 | 11.1.1 | Survey of PCR, microarrays, Capillary | 1d? | 2006-01-04 | 2006-01-04 |  |  |  | 521d |  |
| 511 | 11.1.2 | Gather Zehr's requirements | 1d? | 2006-01-04 | 2006-01-04 |  |  |  | 521d |  |

Notes:
- 510: PCR - LLNL / Microarrays - Dave Walt's microbead / Capillary - Japan

| ID | WBS | Task | Duration | Start | Finish | Baseline start | Baseline finish | Baseline duration | Total slack | Constraint | Work |
| --- | --- | --- | --- | --- | --- | --- | --- | --- | --- | --- | --- |
| 512 | 11.2 | **evaluate existing analytical modules - candidacy** | 1d? | 2006-01-04 | 2006-01-04 | 2006-01-04 | 2006-01-04 | 1d? | 521d |  | 224h |
| 513 | 11.2.1 | Sci | 1d? | 2006-01-04 | 2006-01-04 | 2006-01-04 | 2006-01-04 | 1d? | 521d |  |  |
| 514 | 11.2.2 | EE | 1d? | 2006-01-04 | 2006-01-04 | 2006-01-04 | 2006-01-04 | 1d? | 521d |  | 80h |
| 515 | 11.2.3 | ME | 1d? | 2006-01-04 | 2006-01-04 | 2006-01-04 | 2006-01-04 | 1d? | 521d |  | 120h |
| 516 | 11.2.4 | SE | 1d? | 2006-01-04 | 2006-01-04 | 2006-01-04 | 2006-01-04 | 1d? | 521d |  | 24h |
| 517 | 11.3 | **downselect candidate modules - develop test plan** | 1d? | 2007-01-03 | 2007-01-03 | 2006-01-04 | 2006-01-04 | 1d? | 261d | start no earlier than 2007-01-03 | 88h |
| 518 | 11.3.1 | Sci | 1d? | 2007-01-03 | 2007-01-03 | 2006-01-04 | 2006-01-04 | 1d? | 261d |  |  |
| 519 | 11.3.2 | EE | 1d? | 2007-01-03 | 2007-01-03 | 2006-01-04 | 2006-01-04 | 1d? | 261d |  | 24h |
| 520 | 11.3.3 | ME | 1d? | 2007-01-03 | 2007-01-03 | 2006-01-04 | 2006-01-04 | 1d? | 261d |  | 40h |
| 521 | 11.3.4 | SE | 1d? | 2007-01-03 | 2007-01-03 | 2006-01-04 | 2006-01-04 | 1d? | 261d |  | 24h |
| 522 | 11.4 | **develop lab test fixture that incorps elements of ESP and analytical modules** | 1d? | 2008-01-03 | 2008-01-03 | 2006-01-04 | 2006-01-04 | 1d? | 0d | start no earlier than 2008-01-03 | 896h |
| 523 | 11.4.1 | Sci | 1d? | 2008-01-03 | 2008-01-03 | 2006-01-04 | 2006-01-04 | 1d? | 0d |  |  |
| 524 | 11.4.2 | EE | 1d? | 2008-01-03 | 2008-01-03 | 2006-01-04 | 2006-01-04 | 1d? | 0d |  | 176h |
| 525 | 11.4.3 | ME | 1d? | 2008-01-03 | 2008-01-03 | 2006-01-04 | 2006-01-04 | 1d? | 0d |  | 240h |
| 526 | 11.4.4 | SE | 1d? | 2008-01-03 | 2008-01-03 | 2006-01-04 | 2006-01-04 | 1d? | 0d |  | 80h |
| 527 | 11.4.5 | ME Tech | 1d? | 2008-01-03 | 2008-01-03 | 2006-01-04 | 2006-01-04 | 1d? | 0d |  | 160h |
| 528 | 11.4.6 | EE Tech | 1d? | 2008-01-03 | 2008-01-03 | 2006-01-04 | 2006-01-04 | 1d? | 0d |  | 80h |
| 529 | 11.4.7 | Shop | 1d? | 2008-01-03 | 2008-01-03 | 2006-01-04 | 2006-01-04 | 1d? | 0d |  | 160h |
